Schedule from MS Project, 2005-02-09 to 2009-01-13.

## Calendars

- Standard: Mon-Fri 08:00-12:00, 13:00-17:00; Sat-Sun off.

## Resources

| Resource |
| --- |
| IEA: Business Architecture Team |
| IEA: Data Architecture Team |
| None |
| Solution Architecture Team |
| Office of Acquisition and Property Management |
| Core Modernization Blueprint Team |
| Core Modernization Implementation Team |
| Interior Business Architecture Team |
| Investment Review Board |
| Architecture Review Board |
| Interior Architecture Working Group |
| Enterprise Architect |
| Business Owner |
| System Owner |
| Subject Matter Expert |
| Executive Sponsor |
| Stakeholder |
| IT Portfolio Management |
| Chief Architect |
| Interior Enterprise Architecture |
| Communications Specialist |
| eGovernment Team |
| Enterprise Level Artifact Administrators |
| Data Reference Model Steering Group |
| BPR Specialist |
| Portfolio Owner |
| Chief Technology Officer |
| Development Team |

## Schedule

| ID | WBS | Task | Type | Duration | Start | Finish | Predecessors | Total slack | Free slack | Text24 | Text30 | Text13 | Text1 | Text2 | Text3 | Text4 | Text14 |
| --- | --- | --- | --- | --- | --- | --- | --- | --- | --- | --- | --- | --- | --- | --- | --- | --- | --- |
| 1 | 1 | **Methodology for Business Transformation v1.5** |  | 1025d | 2005-02-09 | 2009-01-13 |  | 0d |  |  |  |  |  |  |  |  |  |
| 2 | 1.1 | **Phase 1: Select the Business Areas to Blueprint** |  | 15d | 2005-02-09 | 2005-03-01 |  | 930d |  |  |  |  |  |  |  |  |  |
| 3 | 1.1.1 | **Step A: Prioritize and select business areas to blueprint** |  | 15d | 2005-02-09 | 2005-03-01 |  | 930d |  | Jim | Jerad |  |  |  |  |  |  |
| 4 | 1.1.1.1 | Define/Validate the enterprise’s business areas |  | 5d | 2005-02-09 | 2005-02-15 |  | 930d | 0d |  |  | IEA: Business Architecture Team |  |  |  |  |  |
| 5 | 1.1.1.2 | Business Areas Visual | milestone | 0d | 2005-02-15 | 2005-02-15 | 4 | 1020d |  |  |  | IEA: Business Architecture Team | Yes | Yes | Yes | Done | Medium |
| 6 | 1.1.1.3 | Define/Validate the criteria for evaluating the business areas to Blueprint |  | 5d | 2005-02-09 | 2005-02-15 |  | 930d | 0d |  |  |  |  |  |  |  |  |
| 7 | 1.1.1.4 | Business Areas Scoring Template | milestone | 0d | 2005-02-15 | 2005-02-15 | 6 | 930d | 0d |  |  | IEA: Business Architecture Team | Yes | Yes | Yes | Done | Medium |
| 8 | 1.1.1.5 | Evaluate the business areas and select candidates to Blueprint |  | 5d | 2005-02-16 | 2005-02-22 | 4, 7 | 930d | 0d |  |  |  |  |  |  |  |  |
| 9 | 1.1.1.6 | Business Areas Scoring | milestone | 0d | 2005-02-22 | 2005-02-22 | 8 | 1015d |  |  |  | IEA: Business Architecture Team | Yes | Yes | Yes | Done | Medium |
| 10 | 1.1.1.7 | Business Areas Prioritization Chart | milestone | 0d | 2005-02-22 | 2005-02-22 | 8 | 1015d |  |  |  | IEA: Business Architecture Team | Yes | Yes | Yes | Done | Medium |
| 11 | 1.1.1.8 | Present the candidates and obtain executive approval to Blueprint |  | 5d | 2005-02-23 | 2005-03-01 | 8 | 930d | 0d |  |  |  |  |  |  |  |  |
| 12 | 1.1.1.9 | Business Areas Prioritization Presentation | milestone | 0d | 2005-03-01 | 2005-03-01 | 11 | 1010d |  |  |  | IEA: Business Architecture Team | Yes | Yes | Yes | Done | Medium |
| 13 | 1.1.1.10 | Record of Decision for Business Area to Blueprint | milestone | 0d | 2005-03-01 | 2005-03-01 | 11 | 1010d |  |  |  | IEA: Business Architecture Team | Yes | Yes | Yes | Done | Medium |
| 14 | 1.1.1.11 | Enterprise Transition Strategy | milestone | 0d | 2005-03-01 | 2005-03-01 | 11 | 930d | 0d |  |  | IEA: Business Architecture Team | Yes | Yes | Yes | Done | Medium |
| 15 | 1.2 | **Phase 2: Prepare for the Blueprint** |  | 80d | 2005-03-02 | 2005-06-21 |  | 930d |  |  |  |  |  |  |  |  |  |
| 16 | 1.2.1 | **Step B: Identify Ownership and Executive Sponsor** |  | 5d | 2005-03-02 | 2005-03-08 |  | 930d |  | Jim | Jerad |  |  |  |  |  |  |
| 17 | 1.2.1.1 | Communicate to leadership the projected time and resource commitments for the study |  | 5d | 2005-03-02 | 2005-03-08 | 14 | 1005d |  |  |  | IEA: Business Architecture Team |  |  |  |  |  |
| 18 | 1.2.1.2 | Reach a decision on who will be the Executive Sponsor for the study |  | 5d | 2005-03-02 | 2005-03-08 | 14 | 1005d |  |  |  |  |  |  |  |  |  |
| 19 | 1.2.1.3 | Perform a more detailed training session for the leadership |  | 5d | 2005-03-02 | 2005-03-08 | 14 | 1005d |  |  |  |  |  |  |  |  |  |
| 20 | 1.2.1.4 | Develop purpose statement for the Blueprint |  | 5d | 2005-03-02 | 2005-03-08 | 14 | 930d | 0d |  |  |  |  |  |  |  |  |
| 21 | 1.2.1.5 | Blueprint Purpose Statement | milestone | 0d | 2005-03-08 | 2005-03-08 | 20 | 930d | 0d |  |  | IEA: Business Architecture Team | Yes | Yes | Yes | Done | Medium |
| 22 | 1.2.2 | **Step C: Form the Core Team** |  | 75d | 2005-03-09 | 2005-06-21 |  | 930d |  | Jim | Jerad |  |  |  |  |  |  |
| 23 | 1.2.2.1 | Executive Sponsor solicits Core Team members |  | 30d | 2005-03-09 | 2005-04-19 | 21 | 930d | 0d |  |  | IEA: Business Architecture Team |  |  |  |  |  |
| 24 | 1.2.2.2 | Core Team Solicitation Memorandum | milestone | 0d | 2005-04-19 | 2005-04-19 | 23 | 930d | 0d |  |  | IEA: Business Architecture Team | Yes | Yes | Yes | Done | Medium |
| 25 | 1.2.2.3 | Establish the Core Team Lead |  | 15d | 2005-04-20 | 2005-05-10 | 24 | 930d | 0d |  |  |  |  |  |  |  |  |
| 26 | 1.2.2.4 | Core Team Formation Memorandum | milestone | 0d | 2005-05-10 | 2005-05-10 | 25 | 930d | 0d |  |  | IEA: Business Architecture Team | Yes | Yes | Yes | Done | Medium |
| 27 | 1.2.2.5 | Provide the Core Team with an orientation |  | 5d | 2005-05-11 | 2005-05-17 | 26 | 930d | 0d |  |  |  |  |  |  |  |  |
| 28 | 1.2.2.6 | Create and sign Commitment Agreement |  | 25d | 2005-05-18 | 2005-06-21 | 27 | 930d | 0d |  |  |  |  |  |  |  |  |
| 29 | 1.2.2.7 | Core Team Commitment Agreement | milestone | 0d | 2005-06-21 | 2005-06-21 | 28 | 930d |  |  |  | IEA: Business Architecture Team | Yes | Yes | Yes | Done | Medium |

Notes:
- 5: Concept for implementation in System Architect: / New Object "Stake Holder" / property "Type" (Person, Org) / property "Priority" / property "Persons" relation / property "Organizations" relationo / property "Child Stakeholder Types" / Hierarchy Diagram to Associate. / Review EAMS for stake holder implementation.
- 7: Concept for implementation in System Architect: / New Object "Stake Holder" / property "Type" (Person, Org) / property "Priority" / property "Persons" relation / property "Organizations" relationo / property "Child Stakeholder Types" / Hierarchy Diagram to Associate. / Review EAMS for stake holder implementation.
- 9: Concept for implementation in System Architect: / New Object "Stake Holder" / property "Type" (Person, Org) / property "Priority" / property "Persons" relation / property "Organizations" relationo / property "Child Stakeholder Types" / Hierarchy Diagram to Associate. / Review EAMS for stake holder implementation.
- 10: Concept for implementation in System Architect: / New Object "Stake Holder" / property "Type" (Person, Org) / property "Priority" / property "Persons" relation / property "Organizations" relationo / property "Child Stakeholder Types" / Hierarchy Diagram to Associate. / Review EAMS for stake holder implementation.
- 12: Concept for implementation in System Architect: / New Object "Stake Holder" / property "Type" (Person, Org) / property "Priority" / property "Persons" relation / property "Organizations" relationo / property "Child Stakeholder Types" / Hierarchy Diagram to Associate. / Review EAMS for stake holder implementation.
- 13: Concept for implementation in System Architect: / New Object "Stake Holder" / property "Type" (Person, Org) / property "Priority" / property "Persons" relation / property "Organizations" relationo / property "Child Stakeholder Types" / Hierarchy Diagram to Associate. / Review EAMS for stake holder implementation.
- 14: Concept for implementation in System Architect: / New Object "Stake Holder" / property "Type" (Person, Org) / property "Priority" / property "Persons" relation / property "Organizations" relationo / property "Child Stakeholder Types" / Hierarchy Diagram to Associate. / Review EAMS for stake holder implementation.
- 21: Concept for implementation in System Architect: / New Object "Stake Holder" / property "Type" (Person, Org) / property "Priority" / property "Persons" relation / property "Organizations" relationo / property "Child Stakeholder Types" / Hierarchy Diagram to Associate. / Review EAMS for stake holder implementation.
- 24: Concept for implementation in System Architect: / New Object "Stake Holder" / property "Type" (Person, Org) / property "Priority" / property "Persons" relation / property "Organizations" relationo / property "Child Stakeholder Types" / Hierarchy Diagram to Associate. / Review EAMS for stake holder implementation.
- 26: Concept for implementation in System Architect: / New Object "Stake Holder" / property "Type" (Person, Org) / property "Priority" / property "Persons" relation / property "Organizations" relationo / property "Child Stakeholder Types" / Hierarchy Diagram to Associate. / Review EAMS for stake holder implementation.
- 29: Concept for implementation in System Architect: / New Object "Stake Holder" / property "Type" (Person, Org) / property "Priority" / property "Persons" relation / property "Organizations" relationo / property "Child Stakeholder Types" / Hierarchy Diagram to Associate. / Review EAMS for stake holder implementation.

| ID | WBS | Task | Type | Duration | Start | Finish | Predecessors | Total slack | Free slack | Text24 | Text30 | Text13 | Text23 | Text1 | Text2 | Text3 | Text4 | Text14 | Text18 |
| --- | --- | --- | --- | --- | --- | --- | --- | --- | --- | --- | --- | --- | --- | --- | --- | --- | --- | --- | --- |
| 30 | 1.3 | **Phase 3: Complete the Blueprint** |  | 305d | 2005-02-09 | 2006-04-11 |  | 0d |  |  |  |  |  |  |  |  |  |  |  |
| 31 | 1.3.1 | **Step 1: Perform Blueprint Project Management** |  | 55d | 2005-02-09 | 2005-04-26 |  | 0d |  | Jim | Jerad |  |  |  |  |  |  |  |  |
| 32 | 1.3.1.1 | Establish the Core Team Charter |  | 30d | 2005-02-09 | 2005-03-22 |  | 970d | 0d |  |  | IEA: Business Architecture Team | Yes |  |  |  |  |  |  |
| 33 | 1.3.1.2 | Core Team Charter | milestone | 0d | 2005-03-22 | 2005-03-22 | 32 | 995d |  |  |  | IEA: Business Architecture Team |  | Yes | Yes | Yes | Done | Medium |  |
| 34 | 1.3.1.3 | Establish the communications strategy for the Blueprint |  | 25d | 2005-03-23 | 2005-04-26 | 32 | 970d | 0d |  |  | IEA: Business Architecture Team,IEA: Data Architecture Team |  |  |  |  |  |  |  |
| 35 | 1.3.1.4 | Communications Strategy | milestone | 0d | 2005-04-26 | 2005-04-26 | 34 | 970d | 0d |  |  | IEA: Business Architecture Team |  | Yes | Yes | Yes | Done | Medium |  |
| 36 | 1.3.1.5 | Communications Plan | milestone | 0d | 2005-04-26 | 2005-04-26 | 35 | 970d |  |  |  | IEA: Business Architecture Team |  | Yes | Yes | Yes | Done | Medium |  |
| 37 | 1.3.1.6 | Establish the project plan for the Blueprint |  | 20d | 2005-02-09 | 2005-03-08 |  | 0d |  |  |  | IEA: Business Architecture Team |  |  |  |  |  |  |  |
| 38 | 1.3.1.7 | Blueprint Project Plan | milestone | 0d | 2005-03-08 | 2005-03-08 | 37 | 1005d |  |  |  | IEA: Business Architecture Team |  | Yes | Yes | Yes | Done | Medium |  |
| 39 | 1.3.2 | **Step 2: Analyze stakeholders / drivers and define the target business strategy** |  | 95d | 2005-03-09 | 2005-07-19 |  | 0d |  | Jim | Jerad |  |  |  |  |  |  |  |  |
| 40 | 1.3.2.1 | Determine and prioritize business area stakeholders and drivers |  | 5d | 2005-03-09 | 2005-03-15 | 37 | 0d |  |  |  | IEA: Business Architecture Team |  |  |  |  |  |  |  |
| 41 | 1.3.2.2 | Stakeholder Hierarchy Diagram and Prioritized List | milestone | 0d | 2005-03-15 | 2005-03-15 | 40 | 955d |  |  |  | IEA: Business Architecture Team |  | Yes | Yes | Yes | Done | Medium |  |
| 42 | 1.3.2.3 | Business Drivers/Mandates Hierarchy Diagram and Prioritized List | milestone | 0d | 2005-03-15 | 2005-03-15 | 40 | 955d |  |  |  | IEA: Business Architecture Team |  | Yes | Yes | Yes | Done | Medium |  |
| 43 | 1.3.2.4 | Conduct stakeholder interviews to determine needs |  | 30d | 2005-03-16 | 2005-04-26 | 40 | 0d |  |  |  | IEA: Business Architecture Team | Yes |  |  |  |  |  |  |
| 44 | 1.3.2.5 | Stakeholder Exchange Diagrams | milestone | 0d | 2005-04-26 | 2005-04-26 | 43 | 925d |  |  |  | IEA: Business Architecture Team,IEA: Data Architecture Team |  | Yes | Yes |  | Done | High |  |
| 45 | 1.3.2.6 | SWOT Diagram | milestone | 0d | 2005-04-26 | 2005-04-26 | 43 | 925d |  |  |  | IEA: Business Architecture Team |  | Yes |  | Yes | Done |  |  |
| 46 | 1.3.2.7 | Perform Organizational Readiness Assessment |  | 10d | 2005-03-16 | 2005-03-29 | 40 | 20d | 0d |  |  | IEA: Business Architecture Team,IEA: Data Architecture Team |  |  |  |  |  |  |  |
| 47 | 1.3.2.8 | Organizational Readiness Assessment | milestone | 0d | 2005-03-29 | 2005-03-29 | 46 | 945d |  |  |  | IEA: Business Architecture Team |  | Yes | Yes | Yes | Done | Medium |  |
| 48 | 1.3.2.9 | Define the business area vision based on stakeholder needs and drivers |  | 5d | 2005-04-27 | 2005-05-03 | 43, 46 | 0d |  |  |  | IEA: Business Architecture Team |  |  |  |  |  |  |  |
| 49 | 1.3.2.10 | Vision Document | milestone | 0d | 2005-05-03 | 2005-05-03 | 48 | 920d |  |  |  | IEA: Business Architecture Team | Yes | Yes |  |  | N/A |  | Yes |
| 50 | 1.3.2.11 | Document and baseline goals/objectives and map to parent organization's goals/objectives |  | 20d | 2005-05-04 | 2005-05-31 | 48 | 0d |  |  |  | IEA: Business Architecture Team |  |  |  |  |  |  |  |
| 51 | 1.3.2.12 | Goals and Objectives Hierarchy Diagram with Baseline Data | milestone | 0d | 2005-05-31 | 2005-05-31 | 50 | 900d |  |  |  | IEA: Business Architecture Team |  | Yes | Yes | Yes | Done | Done |  |
| 52 | 1.3.2.13 | Business Area Goals and Objectives to Parent Organization's Goals and Objectives Matrix | milestone | 0d | 2005-05-31 | 2005-05-31 | 50 | 900d |  |  |  | IEA: Business Architecture Team |  |  | Yes |  | DONE | High |  |
| 53 | 1.3.2.14 | Business Area Balanced Scorecard | milestone | 0d | 2005-05-31 | 2005-05-31 | 50 | 900d |  |  |  |  |  |  |  |  |  |  |  |
| 54 | 1.3.2.15 | Business Area Strategy to Mandates Matrix | milestone | 0d | 2005-05-31 | 2005-05-31 | 50 | 900d |  |  |  | IEA: Business Architecture Team |  | Yes | Yes | Yes | Done | Medium |  |
| 55 | 1.3.2.16 | Define business products and services and target maturity levels |  | 30d | 2005-06-01 | 2005-07-12 | 50 | 0d |  |  |  | IEA: Business Architecture Team |  |  |  |  |  |  |  |
| 56 | 1.3.2.17 | Business Area Products and Services Maturity Model | milestone | 0d | 2005-07-12 | 2005-07-12 | 55 | 870d |  |  |  | IEA: Business Architecture Team |  | Yes | Yes | Yes | Done | Medium |  |
| 57 | 1.3.2.18 | Formulate business strategy results and brief to governance teams |  | 5d | 2005-07-13 | 2005-07-19 | 55 | 0d |  |  |  |  |  |  |  |  |  |  |  |
| 58 | 1.3.2.19 | Presentation on Business Area Strategy and Product and Services | milestone | 0d | 2005-07-19 | 2005-07-19 | 57 | 865d |  |  |  | IEA: Business Architecture Team |  | Yes | Yes | Yes | Done | Medium |  |

Notes:
- 33: Concept for implementation in System Architect: / New Object "Stake Holder" / property "Type" (Person, Org) / property "Priority" / property "Persons" relation / property "Organizations" relationo / property "Child Stakeholder Types" / Hierarchy Diagram to Associate. / Review EAMS for stake holder implementation.
- 35: Concept for implementation in System Architect: / New Object "Stake Holder" / property "Type" (Person, Org) / property "Priority" / property "Persons" relation / property "Organizations" relationo / property "Child Stakeholder Types" / Hierarchy Diagram to Associate. / Review EAMS for stake holder implementation.
- 36: Concept for implementation in System Architect: / New Object "Stake Holder" / property "Type" (Person, Org) / property "Priority" / property "Persons" relation / property "Organizations" relationo / property "Child Stakeholder Types" / Hierarchy Diagram to Associate. / Review EAMS for stake holder implementation.
- 38: Concept for implementation in System Architect: / New Object "Stake Holder" / property "Type" (Person, Org) / property "Priority" / property "Persons" relation / property "Organizations" relationo / property "Child Stakeholder Types" / Hierarchy Diagram to Associate. / Review EAMS for stake holder implementation.
- 41: Concept for implementation in System Architect: / New Object "Stake Holder" / property "Type" (Person, Org) / property "Priority" / property "Persons" relation / property "Organizations" relationo / property "Child Stakeholder Types" / Hierarchy Diagram to Associate. / Review EAMS for stake holder implementation.
- 42: Concept for implementation in System Architect: / New Object "Stake Holder" / property "Type" (Person, Org) / property "Priority" / property "Persons" relation / property "Organizations" relationo / property "Child Stakeholder Types" / Hierarchy Diagram to Associate. / Review EAMS for stake holder implementation.
- 44: Concept for implementation in System Architect: / New Diagram Type "Stake Holder Interactio" / Utilize BFA, and Stake Holder as Node Symbols. / Utilize ICOM Arrow as line.
- 45: Concept for implementation in System Architect: / ?? Possibly use Explorer Diagram. / Use Existing TAA Implementation with renames of Issue to Business Driver, and remove all TAA reference. / Associate issue with Person and Organization. / Depending on reporting may type to handle things like filtering on mandates, governance, and stakeholder feedback. / See EAMS for possible implementation. / May do diagram or not depending on communication feasibility.
- 47: Concept for implementation in System Architect: / New Object "Stake Holder" / property "Type" (Person, Org) / property "Priority" / property "Persons" relation / property "Organizations" relationo / property "Child Stakeholder Types" / Hierarchy Diagram to Associate. / Review EAMS for stake holder implementation.
- 49: Concept for implementation in System Architect: / New property on BFA or utilize v10 document attachment.
- 51: Concept for implementation in System Architect: / Use Explorer Diagram to select PRM elements to associage to the Business Focus Area. / Filtered by BFA.
- 54: Concept for implementation in System Architect: / Utilize the Business Driver object (where type is governance/mandate). / Possibly use a standard SA Matrix. / Possibly utilize and upgrade Albert D. matrix macro.
- 56: Concept for implementation in System Architect: / Utilize the Business Driver object (where type is governance/mandate). / Possibly use a standard SA Matrix. / Possibly utilize and upgrade Albert D. matrix macro.
- 58: Concept for implementation in System Architect: / Utilize the Business Driver object (where type is governance/mandate). / Possibly use a standard SA Matrix. / Possibly utilize and upgrade Albert D. matrix macro.

| ID | WBS | Task | Type | Duration | Start | Finish | Predecessors | Total slack | Free slack | Text24 | Text30 | Text13 | Text1 | Text2 | Text4 | Text14 | Text23 | Text18 | Text3 |
| --- | --- | --- | --- | --- | --- | --- | --- | --- | --- | --- | --- | --- | --- | --- | --- | --- | --- | --- | --- |
| 59 | 1.3.3 | **Step 3: Analyze the business and define the target business environment** |  | 60d | 2005-07-20 | 2005-10-11 |  | 0d |  | Jerad | Fred |  |  |  |  |  |  |  |  |
| 60 | 1.3.3.1 | Determine the value chain for the business area |  | 5d | 2005-07-20 | 2005-07-26 | 57 | 0d |  |  |  | IEA: Business Architecture Team |  |  |  |  |  |  |  |
| 61 | 1.3.3.2 | As-Is Value Chain Diagram | milestone | 0d | 2005-07-26 | 2005-07-26 | 60 | 905d |  |  |  | IEA: Business Architecture Team | Yes | Yes | DONE | High |  |  |  |
| 62 | 1.3.3.3 | Target Value Chain Diagram | milestone | 0d | 2005-07-26 | 2005-07-26 | 60 | 905d |  |  |  | IEA: Business Architecture Team | Yes | Yes | DONE | High |  |  |  |
| 63 | 1.3.3.4 | Decompose the business function model |  | 5d | 2005-07-27 | 2005-08-02 | 60 | 0d |  |  |  | IEA: Business Architecture Team,IEA: Data Architecture Team |  |  |  |  | Yes |  |  |
| 64 | 1.3.3.5 | As-Is Business Function Model | milestone | 0d | 2005-08-02 | 2005-08-02 | 63 | 900d |  |  |  | IEA: Business Architecture Team |  | Yes | DONE | Done |  |  |  |
| 65 | 1.3.3.6 | Target Business Function Model | milestone | 0d | 2005-08-02 | 2005-08-02 | 63 | 900d |  |  |  |  |  |  |  |  |  |  |  |
| 66 | 1.3.3.7 | Analyze the current processes and their performance |  | 15d | 2005-08-03 | 2005-08-23 | 63 | 0d |  |  |  | IEA: Business Architecture Team |  |  |  |  |  |  |  |
| 67 | 1.3.3.8 | Existing Investments to Processes Matrix | milestone | 0d | 2005-08-23 | 2005-08-23 | 66 | 885d |  |  |  | IEA: Business Architecture Team | Yes | Yes | DONE | Medium |  |  |  |
| 68 | 1.3.3.9 | As-Is Swim Lane Diagram (actual organizations) | milestone | 0d | 2005-08-23 | 2005-08-23 | 66 | 885d |  |  |  | IEA: Business Architecture Team | Yes | Yes | DONE | Done |  |  |  |
| 69 | 1.3.3.10 | As-is IDEF0 Diagrams for Critical Value Chain Processes | milestone | 0d | 2005-08-23 | 2005-08-23 | 66 | 885d |  |  |  |  |  |  |  |  |  |  |  |
| 70 | 1.3.3.11 | Define key target processes / data and their target performance |  | 25d | 2005-08-24 | 2005-09-27 | 66 | 0d |  |  |  | IEA: Business Architecture Team,IEA: Data Architecture Team |  |  |  |  |  |  |  |
| 71 | 1.3.3.12 | Target Swim Lane Diagram (conceptual organizations) | milestone | 0d | 2005-09-27 | 2005-09-27 | 70 | 860d |  |  |  | IEA: Business Architecture Team,IEA: Data Architecture Team | Yes | Yes | DONE | Done |  |  |  |
| 72 | 1.3.3.13 | Target IDEF0 Diagrams for Critical Value Chain Processes | milestone | 0d | 2005-09-27 | 2005-09-27 | 70 | 860d |  |  |  | IEA: Business Architecture Team | Yes | Yes | DONE | Done |  |  |  |
| 73 | 1.3.3.14 | Target Data Stewardship Matrix | milestone | 0d | 2005-09-27 | 2005-09-27 | 70 | 860d |  |  |  | IEA: Business Architecture Team |  |  | N/A |  |  | Yes |  |
| 74 | 1.3.3.15 | Target Information Services Matrix | milestone | 0d | 2005-09-27 | 2005-09-27 | 70 | 860d |  |  |  |  |  |  |  |  |  |  |  |
| 75 | 1.3.3.16 | Entity Relationship Diagram | milestone | 0d | 2005-09-27 | 2005-09-27 | 70 | 815d | 35d |  |  | IEA: Business Architecture Team,IEA: Data Architecture Team | Yes | Yes | DONE | High |  |  |  |
| 76 | 1.3.3.17 | Target Logical Data Model | milestone | 0d | 2005-09-27 | 2005-09-27 | 70 | 860d |  |  |  | IEA: Business Architecture Team |  |  | N/A |  |  | Yes |  |
| 77 | 1.3.3.18 | Target Business Activity to Data Entity CRUD Matrix | milestone | 0d | 2005-09-27 | 2005-09-27 | 70 | 860d |  |  |  | IEA: Business Architecture Team | Yes |  | N/A | High |  |  | Yes |
| 78 | 1.3.3.19 | Formulate the business analysis results and brief to governance teams |  | 10d | 2005-09-28 | 2005-10-11 | 70 | 0d |  |  |  | IEA: Business Architecture Team,IEA: Data Architecture Team | Yes | Yes | DONE | Done |  |  |  |
| 79 | 1.3.3.20 | Business and Data Analysis Presentation | milestone | 0d | 2005-10-11 | 2005-10-11 | 78 | 0d |  |  |  | IEA: Business Architecture Team | Yes | Yes | DONE | Medium |  |  |  |
| 80 | 1.3.4 | **Step 4: Analyze the IT and develop the target conceptual solution architecture** |  | 85d | 2005-07-20 | 2005-11-15 |  | 60d |  | Albert | Fred |  |  |  |  |  |  |  |  |
| 81 | 1.3.4.1 | Assess and score the existing IT portfolio |  | 45d | 2005-07-20 | 2005-09-20 | 39 | 865d | 0d |  |  | IEA: Business Architecture Team,IEA: Data Architecture Team |  |  |  |  |  |  |  |
| 82 | 1.3.4.2 | Initial Business Focus Area Metadata | milestone | 0d | 2005-09-20 | 2005-09-20 | 81 | 865d |  |  |  | None |  |  | N/A | High |  |  | Yes |
| 83 | 1.3.4.3 | As-Is System Interface Diagram | milestone | 0d | 2005-09-20 | 2005-09-20 | 81 | 865d |  |  |  | None | Yes | Yes | DONE | Done |  |  |  |
| 84 | 1.3.4.4 | Systems and Services Description and Scoring (As-Is) | milestone | 0d | 2005-09-20 | 2005-09-20 | 81 | 865d |  |  |  | IEA: Data Architecture Team,IEA: Business Architecture Team | Yes |  | DONE | Low |  |  | Yes |
| 85 | 1.3.4.5 | Total Cost of Ownership | milestone | 0d | 2005-09-20 | 2005-09-20 | 81 | 865d |  |  |  | IEA: Data Architecture Team,IEA: Business Architecture Team | Yes |  | DONE | Low |  |  | Yes |
| 86 | 1.3.4.6 | Enterprise Architecture Repository Portfolio Reports | milestone | 0d | 2005-09-20 | 2005-09-20 | 81 | 865d |  |  |  | IEA: Data Architecture Team,IEA: Business Architecture Team | Yes |  | DONE | Low |  |  | Yes |
| 87 | 1.3.4.7 | ADS Analysis: As-Is Data Store to Target Logical Data Model Entity Matrix | milestone | 0d | 2005-09-20 | 2005-09-20 | 81 | 865d |  |  |  | None |  |  | DONE | Done |  |  | Yes |
| 88 | 1.3.4.8 | ADS Analysis: As-Is Data Store ADS Assessment Matrix | milestone | 0d | 2005-09-20 | 2005-09-20 | 81 | 865d |  |  |  | None | Yes |  | N/A |  |  |  |  |
| 89 | 1.3.4.9 | ADS Analysis: ADS Scoring Summary | milestone | 0d | 2005-09-20 | 2005-09-20 | 81 | 865d |  |  |  | None | Yes |  | N/A |  |  |  |  |
| 90 | 1.3.4.10 | Develop the target conceptual solution architecture |  | 10d | 2005-10-12 | 2005-10-25 | 79 | 0d |  |  |  | None |  |  |  |  |  |  |  |
| 91 | 1.3.4.11 | Systems and Services Description and Scoring (Target) | milestone | 0d | 2005-10-25 | 2005-10-25 | 90 | 840d |  |  |  | None | Yes | Yes | NEED | Medium |  |  |  |
| 92 | 1.3.4.12 | Integrated Target Services and Systems Model | milestone | 0d | 2005-10-25 | 2005-10-25 | 90 | 840d |  |  |  | None | Yes | Yes | NEED | Medium |  |  |  |
| 93 | 1.3.4.13 | Solution Architecture Document | milestone | 0d | 2005-10-25 | 2005-10-25 | 90 | 840d |  |  |  | None |  |  | N/A | High |  |  | Yes |
| 94 | 1.3.4.14 | Verify the target conceptual solution architecture complies with the EA |  | 5d | 2005-10-26 | 2005-11-01 | 90 | 0d |  |  |  | IEA: Business Architecture Team,IEA: Data Architecture Team |  |  |  |  |  |  |  |
| 95 | 1.3.4.15 | Determine the gaps between the current IT portfolio and the target |  | 5d | 2005-11-02 | 2005-11-08 | 94 | 0d |  |  |  | IEA: Data Architecture Team |  |  |  |  |  |  |  |
| 96 | 1.3.4.16 | Architecture Decision Document | milestone | 0d | 2005-11-08 | 2005-11-08 | 95 | 830d |  |  |  | IEA: Data Architecture Team | Yes |  | NEED | Medium |  |  | Yes |
| 97 | 1.3.4.17 | Formulate the IT analysis results and brief to governance teams |  | 5d | 2005-11-09 | 2005-11-15 | 95 | 0d |  |  |  | None |  |  |  |  |  |  |  |
| 98 | 1.3.4.18 | Presentation on Systems, Services, and Investments Analysis | milestone | 0d | 2005-11-15 | 2005-11-15 | 97 | 0d |  |  |  | IEA: Business Architecture Team | Yes |  | N/A | High |  |  | Yes |

Notes:
- 61: Concept for implementation in System Architect: / New Diagram Type Name? "Value Chain". / Use of BRM classification and possibly add a priority attribute to the BFA/Function object.
- 62: Concept for implementation in System Architect: / Same as above.
- 68: Swimlanes
- 71: Concept for implementation in System Architect: / Same as business area value chain, or use traditional IDEF 0.
- 72: Swimlanes
- 75: ERD
- 78: Concept for implementation in System Architect: / Same as business area value chain, or use traditional IDEF 0.
- 83: Concept for implementation in System Architect: / Utilize the existing System Interface Diagram.
- 84: Concept for implementation in System Architect: / Currently implemented but no macro for updating and outputing. / Need BFA Scoring implentation, will be the same as TBA scoring implementation.
- 85: Concept for implementation in System Architect: / Currently implemented but no macro for updating and outputing. / Need BFA Scoring implentation, will be the same as TBA scoring implementation.
- 86: Concept for implementation in System Architect: / Currently implemented but no macro for updating and outputing. / Need BFA Scoring implentation, will be the same as TBA scoring implementation.
- 91: Concept for implementation in System Architect: / Will be BFA Centric System Interface diagram with use of Services. / ALBERT SPACESHIP
- 92: Concept for implementation in System Architect: / Will be BFA Centric System Interface diagram with use of Services. / ALBERT SPACESHIP
- 96: Concept for implementation in System Architect: / Same as above.

| ID | WBS | Task | Type | Duration | Start | Finish | Predecessors | Total slack | Free slack | Text24 | Text30 | Text13 | Text23 | Text1 | Text3 | Text4 | Text14 | Text18 | Text2 |
| --- | --- | --- | --- | --- | --- | --- | --- | --- | --- | --- | --- | --- | --- | --- | --- | --- | --- | --- | --- |
| 99 | 1.3.5 | **Step 5: Author the Modernization Blueprint and obtain governance approvals** |  | 75d | 2005-11-16 | 2006-02-28 |  | 0d |  | Albert | Fred |  |  |  |  |  |  |  |  |
| 100 | 1.3.5.1 | Define findings, recommendations and implementation alternatives |  | 20d | 2005-11-16 | 2005-12-13 | 98, 75 | 780d | 0d |  |  | IEA: Business Architecture Team,IEA: Data Architecture Team | Yes |  |  |  |  |  |  |
| 101 | 1.3.5.2 | Modernization Recommendations to Horizontal Dependencies Matrix | milestone | 0d | 2005-12-13 | 2005-12-13 | 100 | 805d |  |  |  | IEA: Business Architecture Team,IEA: Data Architecture Team |  | Yes | Yes | NEED | Low |  |  |
| 102 | 1.3.5.3 | Modernization Recommendations to Mandates Matrix | milestone | 0d | 2005-12-13 | 2005-12-13 | 100 | 805d |  |  |  | IEA: Business Architecture Team,IEA: Data Architecture Team |  | Yes | Yes | NEED | Low |  |  |
| 103 | 1.3.5.4 | Modernization Blueprint Findings, Recommendations, and Alternatives Presentation | milestone | 0d | 2005-12-13 | 2005-12-13 | 100 | 805d |  |  |  | IEA: Business Architecture Team,IEA: Data Architecture Team |  | Yes | Yes | NEED | Low | Yes |  |
| 104 | 1.3.5.5 | Apply the VMM to the alternatives and select the proposed implementation alternatives |  | 15d | 2005-12-14 | 2006-01-03 | 100 | 780d | 0d |  |  | IEA: Business Architecture Team,IEA: Data Architecture Team |  |  |  |  |  |  |  |
| 105 | 1.3.5.6 | Value Measuring Methodology Cost to Value Matrix | milestone | 0d | 2006-01-03 | 2006-01-03 | 104 | 790d |  |  |  | IEA: Business Architecture Team,IEA: Data Architecture Team |  | Yes | Yes | NEED | Low | Yes |  |
| 106 | 1.3.5.7 | Validate the proposed implementation alternatives with governance teams |  | 10d | 2006-01-04 | 2006-01-17 | 104 | 780d |  |  |  | IEA: Business Architecture Team,IEA: Data Architecture Team | Yes |  |  |  |  |  |  |
| 107 | 1.3.5.8 | Author draft Modernization Blueprint including transition documentation |  | 20d | 2005-11-16 | 2005-12-13 | 98 | 0d |  |  |  | IEA: Business Architecture Team,IEA: Data Architecture Team |  |  |  |  |  |  |  |
| 108 | 1.3.5.9 | Draft Recommendation Implementation Overview Visual | milestone | 0d | 2005-12-13 | 2005-12-13 | 107 | 805d |  |  |  | None |  |  |  | NEED | Low |  | Yes |
| 109 | 1.3.5.10 | Draft Strategic Systems Migration Diagram | milestone | 0d | 2005-12-13 | 2005-12-13 | 107 | 805d |  |  |  | IEA: Business Architecture Team,IEA: Data Architecture Team |  | Yes |  | DONE |  | Yes |  |
| 110 | 1.3.5.11 | Draft Strategic Sequencing Overview Visual | milestone | 0d | 2005-12-13 | 2005-12-13 | 107 | 805d |  |  |  | IEA: Business Architecture Team,IEA: Data Architecture Team |  | Yes |  | NEED |  | Yes |  |
| 111 | 1.3.5.12 | Draft Implementation Sequencing Plan | milestone | 0d | 2005-12-13 | 2005-12-13 | 107 | 805d |  |  |  | None |  |  |  | NEED | Low |  | Yes |
| 112 | 1.3.5.13 | Draft Modernization Blueprint | milestone | 0d | 2005-12-13 | 2005-12-13 | 107 | 805d |  |  |  | IEA: Business Architecture Team,IEA: Data Architecture Team |  |  |  | NEED | High | Yes |  |
| 113 | 1.3.5.14 | Distribute Modernization Blueprint and incorporate feedback |  | 45d | 2005-12-14 | 2006-02-14 | 107 | 0d |  |  |  | IEA: Business Architecture Team,IEA: Data Architecture Team |  |  |  |  |  |  |  |
| 114 | 1.3.5.15 | Final Recommendation Implementation Overview Visual | milestone | 0d | 2006-02-14 | 2006-02-14 | 113 | 760d |  |  |  | None |  |  |  | NEED | Low |  | Yes |
| 115 | 1.3.5.16 | Final Strategic Systems Migration Diagram | milestone | 0d | 2006-02-14 | 2006-02-14 | 113 | 760d |  |  |  | IEA: Business Architecture Team,IEA: Data Architecture Team |  | Yes |  | DONE |  | Yes |  |
| 116 | 1.3.5.17 | Final Strategic Sequencing Overview Visual | milestone | 0d | 2006-02-14 | 2006-02-14 | 113 | 760d |  |  |  | IEA: Business Architecture Team,IEA: Data Architecture Team |  | Yes |  | NEED |  | Yes |  |
| 117 | 1.3.5.18 | Final Implementation Sequencing Plan | milestone | 0d | 2006-02-14 | 2006-02-14 | 113 | 760d |  |  |  | None |  |  |  | NEED | Low |  | Yes |
| 118 | 1.3.5.19 | Final Modernization Blueprint | milestone | 0d | 2006-02-14 | 2006-02-14 | 113 | 760d |  |  |  | IEA: Business Architecture Team,IEA: Data Architecture Team |  |  |  | NEED | High | Yes |  |
| 119 | 1.3.5.20 | Business and Stakeholder Interaction Log | milestone | 0d | 2006-02-14 | 2006-02-14 | 113 | 760d |  |  |  |  |  |  |  |  |  |  |  |
| 120 | 1.3.5.21 | Feedback Tracking Document and Feedback Action Report | milestone | 0d | 2006-02-14 | 2006-02-14 | 113 | 760d |  |  |  |  |  |  |  |  |  |  |  |
| 121 | 1.3.5.22 | Brief key stakeholders and governance teams, obtain approval, and publish Blueprint |  | 10d | 2006-02-15 | 2006-02-28 | 113 | 0d |  |  |  | IEA: Business Architecture Team,IEA: Data Architecture Team |  |  |  |  |  |  |  |
| 122 | 1.3.5.23 | Modernization Blueprint Presentation | milestone | 0d | 2006-02-28 | 2006-02-28 | 121 | 750d |  |  |  | IEA: Business Architecture Team,IEA: Data Architecture Team |  |  |  | N/A |  | Yes |  |
| 123 | 1.3.5.24 | Record of Decision | milestone | 0d | 2006-02-28 | 2006-02-28 | 121 | 750d |  |  |  | IEA: Business Architecture Team,IEA: Data Architecture Team |  |  |  | N/A |  | Yes |  |

Notes:
- 103: Concept for implementation in System Architect: / Delete relationship from recomendation to Business Driver (formerly issue). / Add new object "Finding" required field possibly. / Relate Finding to Recomendation. / Report is an input to presentation
- 105: Concept for implementation in System Architect: / Delete relationship from recomendation to Business Driver (formerly issue). / Add new object "Finding" required field possibly. / Relate Finding to Recomendation. / Report is an input to presentation
- 110: Concept for implementation in System Architect: / Could use MS Project, and use v10 attachment capability.
- 116: Concept for implementation in System Architect: / Could use MS Project, and use v10 attachment capability.

| ID | WBS | Task | Type | Duration | Start | Finish | Predecessors | Total slack | Free slack | Text24 | Text30 | Text13 | Text2 | Text4 | Text14 | Text3 | Text18 | Text1 | Text23 |
| --- | --- | --- | --- | --- | --- | --- | --- | --- | --- | --- | --- | --- | --- | --- | --- | --- | --- | --- | --- |
| 124 | 1.3.6 | **Step 6: Incorporate approved Modernization Blueprint into enterprise architecture** |  | 30d | 2006-03-01 | 2006-04-11 |  | 0d |  | Jerad | Jim |  |  |  |  |  |  |  |  |
| 125 | 1.3.6.1 | Load target architecture data from approved Modernization Blueprint into EA Repository |  | 30d | 2006-03-01 | 2006-04-11 | 121 | 0d |  |  |  | IEA: Business Architecture Team,IEA: Data Architecture Team |  |  |  |  |  |  |  |
| 126 | 1.3.6.2 | Blueprint Products Loaded | milestone | 0d | 2006-04-11 | 2006-04-11 | 125 | 0d |  |  |  | IEA: Data Architecture Team | Yes | Done | Low |  |  |  |  |
| 127 | 1.3.6.3 | Business Focus Area Metadata Loaded | milestone | 0d | 2006-04-11 | 2006-04-11 | 125 | 0d |  |  |  | IEA: Data Architecture Team | Yes | Done | Low |  |  |  |  |
| 128 | 1.3.6.4 | Update enterprise level products |  | 5d | 2006-03-01 | 2006-03-07 | 121 | 13d | 0d |  |  | IEA: Business Architecture Team,IEA: Data Architecture Team |  |  |  |  |  |  |  |
| 129 | 1.3.6.5 | Enterprise Data Exchange Node Drawing | milestone | 0d | 2006-03-07 | 2006-03-07 | 128 | 25d |  |  |  | IEA: Data Architecture Team | Yes | Done | Low |  |  |  |  |
| 130 | 1.3.6.6 | Enterprise Data Stewardship Matrix | milestone | 0d | 2006-03-07 | 2006-03-07 | 128 | 25d |  |  |  | IEA: Data Architecture Team |  | Done | Low | Yes |  |  |  |
| 131 | 1.3.6.7 | Enterprise Modernization Sequencing Plan | milestone | 0d | 2006-03-07 | 2006-03-07 | 128 | 25d |  |  |  | IEA: Business Architecture Team,IEA: Data Architecture Team |  | Done | Low |  | Yes |  |  |
| 132 | 1.3.6.8 | Enterprise Modernization Dependencies Matrix | milestone | 0d | 2006-03-07 | 2006-03-07 | 128 | 25d |  |  |  | IEA: Business Architecture Team,IEA: Data Architecture Team |  | Done | Low | Yes |  |  |  |
| 133 | 1.3.6.9 | Enterprise Horizontal Services Model | milestone | 0d | 2006-03-07 | 2006-03-07 | 128 | 25d |  |  |  | IEA: Business Architecture Team,IEA: Data Architecture Team | Yes | Done | Low |  |  |  |  |
| 134 | 1.3.6.10 | Enterprise Modernization Recommendations to Mandates Matrix | milestone | 0d | 2006-03-07 | 2006-03-07 | 128 | 25d |  |  |  | IEA: Business Architecture Team,IEA: Data Architecture Team |  | Done | Low | Yes |  |  |  |
| 135 | 1.3.6.11 | Enterprise Modernization Recommendations to Outcomes Matrix | milestone | 0d | 2006-03-07 | 2006-03-07 | 128 | 25d |  |  |  | IEA: Business Architecture Team,IEA: Data Architecture Team |  | Done | Low | Yes |  |  |  |
| 136 | 1.3.6.12 | Department Reference Models | milestone | 0d | 2006-03-07 | 2006-03-07 | 128 | 25d |  |  |  | IEA: Business Architecture Team |  | Done | Low | Yes | Yes |  |  |
| 137 | 1.3.6.13 | Brief the governance teams on the updated enterprise level products |  | 5d | 2006-03-08 | 2006-03-14 | 128 | 13d | 0d |  |  | IEA: Business Architecture Team,IEA: Data Architecture Team |  |  |  |  |  |  |  |
| 138 | 1.3.6.14 | Publish updated enterprise products |  | 2d | 2006-03-15 | 2006-03-16 | 137 | 13d | 0d |  |  |  |  |  |  |  |  |  |  |
| 139 | 1.3.6.15 | Published Enterprise Products | milestone | 0d | 2006-03-16 | 2006-03-16 | 138 | 13d | 0d |  |  | IEA: Business Architecture Team |  | N/A |  |  |  |  |  |
| 140 | 1.3.6.16 | Update the Enterprise Transition Strategy |  | 5d | 2006-03-17 | 2006-03-23 | 139 | 13d | 0d |  |  |  |  |  |  |  |  |  |  |
| 141 | 1.3.6.17 | Updated Enterprise Transition Strategy | milestone | 0d | 2006-03-23 | 2006-03-23 | 140 | 13d |  |  |  | IEA: Business Architecture Team |  | N/A |  |  |  |  |  |
| 142 | 1.4 | **Phase 4: Implement the Blueprint Recommendations** |  | 1025d | 2005-02-09 | 2009-01-13 |  | 0d |  |  |  |  |  |  |  |  |  |  |  |
| 143 | 1.4.1 | **Step 7: Perform business transformation initiation tasks** |  | 25d | 2006-04-12 | 2006-05-16 |  | 0d |  | Jim | Jerad |  |  |  |  |  |  |  |  |
| 144 | 1.4.1.1 | Form Core Modernization Implementation Team (CMIT) with representatives from sponsor business areas |  | 5d | 2006-04-12 | 2006-04-18 | 124 | 0d |  |  |  | IEA: Business Architecture Team |  |  |  |  |  |  |  |
| 145 | 1.4.1.2 | Revise Core Modernization Implementation Team Charter Including Roster | milestone | 0d | 2006-04-18 | 2006-04-18 | 144 | 20d |  |  |  | IEA: Business Architecture Team |  | N/A |  |  | Yes | Yes | Yes |
| 146 | 1.4.1.3 | Develop Project Plan revisions based on IRB priorities and resource commitments |  | 5d | 2006-04-19 | 2006-04-25 | 144 | 0d |  |  |  | IEA: Business Architecture Team |  |  |  |  |  |  |  |
| 147 | 1.4.1.4 | Update BFA Transition Plan (derived from Blueprint Transistion Plan) | milestone | 0d | 2006-04-25 | 2006-04-25 | 146 | 15d |  |  |  | IEA: Business Architecture Team |  | N/A |  |  | Yes | Yes |  |
| 148 | 1.4.1.5 | Integrate with IEA Enterprise Modernization Sequencing Plan | milestone | 0d | 2006-04-25 | 2006-04-25 | 146 | 15d |  |  |  | IEA: Business Architecture Team |  | N/A |  |  | Yes | Yes |  |

Notes:
- 145: Concept for implementation in System Architect: / New Object called "Modernization Team" / Will be associated to "Person" team members. / Will Review possibly type organization as team.
- 147: Concept for implementation in System Architect: / None. / Use MS Project.
- 148: Concept for implementation in System Architect: / None. / Use MS Project.

| ID | WBS | Task | Type | Duration | Start | Finish | Predecessors | Total slack | Free slack | Text13 | Text4 | Text18 | Text23 | Text24 | Text30 | Text1 | Text2 | Text14 | Text3 |
| --- | --- | --- | --- | --- | --- | --- | --- | --- | --- | --- | --- | --- | --- | --- | --- | --- | --- | --- | --- |
| 149 | 1.4.1.6 | **Develop Funding Strategy** |  | 5d | 2006-04-26 | 2006-05-02 |  | 10d |  |  |  |  |  |  |  |  |  |  |  |
| 150 | 1.4.1.6.1 | Based on program plan, develop funding and resources strategy for modernization |  | 5d | 2006-04-26 | 2006-05-02 | 146 | 10d | 0d | IEA: Business Architecture Team |  |  |  |  |  |  |  |  |  |
| 151 | 1.4.1.6.2 | Funding and Resource Strategy Document | milestone | 0d | 2006-05-02 | 2006-05-02 | 150 | 10d |  | IEA: Business Architecture Team | N/A | Yes |  |  |  |  |  |  |  |
| 152 | 1.4.1.7 | **Develop Communications Plan** |  | 5d | 2006-04-26 | 2006-05-02 |  | 0d |  |  |  |  |  |  |  |  |  |  |  |
| 153 | 1.4.1.7.1 | Develop Communications and Outreach Strategy for Implementation |  | 5d | 2006-04-26 | 2006-05-02 | 146 | 0d |  |  |  |  |  |  |  |  |  |  |  |
| 154 | 1.4.1.7.2 | Revise Communications Plan |  | 5d | 2006-04-26 | 2006-05-02 | 146 | 0d |  |  |  |  |  |  |  |  |  |  |  |
| 155 | 1.4.1.7.3 | Revise Program Website |  | 5d | 2006-04-26 | 2006-05-02 | 146 | 0d |  |  |  |  |  |  |  |  |  |  |  |
| 156 | 1.4.1.8 | Develop Risk and Change Management Strategies |  | 5d | 2006-04-26 | 2006-05-02 | 146 | 0d |  | IEA: Business Architecture Team |  |  |  |  |  |  |  |  |  |
| 157 | 1.4.1.9 | Risk Management / Mitigation Plan | milestone | 0d | 2006-05-02 | 2006-05-02 | 156 | 10d |  | IEA: Business Architecture Team | N/A | Yes |  |  |  |  |  |  |  |
| 158 | 1.4.1.10 | Change Management Plan | milestone | 0d | 2006-05-02 | 2006-05-02 | 156 | 10d |  | IEA: Business Architecture Team | N/A | Yes |  |  |  |  |  |  |  |
| 159 | 1.4.1.11 | Communicate Risk and Change Management to Stakeholders |  | 5d | 2006-05-03 | 2006-05-09 | 152, 156 | 0d |  |  |  |  |  |  |  |  |  |  |  |
| 160 | 1.4.1.12 | Brief IBAT/IRB/CTOC on program plan, program status, funding strategy, resource strategy |  | 5d | 2006-05-10 | 2006-05-16 | 159 | 0d |  | IEA: Business Architecture Team |  |  | Yes |  |  |  |  |  |  |
| 161 | 1.4.1.13 | Modernization Program Status Briefing | milestone | 0d | 2006-05-16 | 2006-05-16 | 160 | 0d |  | IEA: Business Architecture Team | N/A | Yes |  |  |  |  |  |  |  |
| 162 | 1.4.2 | **Step 8: Conduct Business Process Reengineering (as necessary)** |  | 95d | 2006-05-17 | 2006-09-26 |  | 465d | 0d |  |  |  |  | Fred | Jim |  |  |  |  |
| 163 | 1.4.2.1 | BPR planning |  | 5d | 2006-05-17 | 2006-05-23 | 143 | 465d | 0d | IEA: Business Architecture Team |  |  |  |  |  |  |  |  |  |
| 164 | 1.4.2.2 | BPR Team Membership Roster Document | milestone | 0d | 2006-05-23 | 2006-05-23 | 163 | 555d |  | IEA: Business Architecture Team | N/A | Yes |  |  |  | Yes |  |  |  |
| 165 | 1.4.2.3 | BPR Scope Document | milestone | 0d | 2006-05-23 | 2006-05-23 | 163 | 555d |  | IEA: Business Architecture Team | N/A | Yes |  |  |  | Yes |  |  |  |
| 166 | 1.4.2.4 | Create/refine (as-is) process baseline |  | 30d | 2006-05-24 | 2006-07-04 | 163 | 465d | 0d | IEA: Business Architecture Team |  |  |  |  |  |  |  |  |  |
| 167 | 1.4.2.5 | Normalized As-Is IDEF0 Diagrams | milestone | 0d | 2006-07-04 | 2006-07-04 | 166 | 525d |  | IEA: Business Architecture Team | N/A |  |  |  |  | Yes | Yes | Done |  |
| 168 | 1.4.2.6 | Updated BFA BRM Hierarchy Diagram (if applicable) | milestone | 0d | 2006-07-04 | 2006-07-04 | 166 | 525d |  | IEA: Business Architecture Team | N/A |  |  |  |  |  | Yes | Done |  |
| 169 | 1.4.2.7 | Updated Conceptual Data Model (if applicable) | milestone | 0d | 2006-07-04 | 2006-07-04 | 166 | 525d |  | IEA: Data Architecture Team | N/A |  |  |  |  | Yes | Yes | Done |  |
| 170 | 1.4.2.8 | Updated Conceptual Data Model to Business Function Matrix (if applicable) | milestone | 0d | 2006-07-04 | 2006-07-04 | 166 | 525d |  | IEA: Business Architecture Team,IEA: Data Architecture Team | N/A |  |  |  |  |  |  | Medium | Yes |
| 171 | 1.4.2.9 | Updated Conceptual Data Entity Stewardship Matrix (if applicable) | milestone | 0d | 2006-07-04 | 2006-07-04 | 166 | 525d |  | IEA: Data Architecture Team | N/A |  |  |  |  | Yes |  | Medium | Yes |
| 172 | 1.4.2.10 | Updated BFA As-Is Services and Systems Diagram (if applicable) | milestone | 0d | 2006-07-04 | 2006-07-04 | 166 | 525d |  | None | N/A |  |  |  |  | Yes | Yes | Medium |  |
| 173 | 1.4.2.11 | Research and benchmarking |  | 30d | 2006-07-05 | 2006-08-15 | 166 | 465d | 0d | IEA: Business Architecture Team,IEA: Data Architecture Team |  |  |  |  |  |  |  |  |  |
| 174 | 1.4.2.12 | Recommendations and Findings for Process Improvement Document | milestone | 0d | 2006-08-15 | 2006-08-15 | 173 | 495d |  | IEA: Business Architecture Team,IEA: Data Architecture Team | N/A | Yes |  |  |  |  |  | Medium |  |
| 175 | 1.4.2.13 | Develop the future (to-be) process |  | 30d | 2006-08-16 | 2006-09-26 | 173 | 465d | 0d | IEA: Business Architecture Team |  |  | Yes |  |  |  |  |  |  |
| 176 | 1.4.2.14 | Normalized As-Is IDEF0 Diagrams | milestone | 0d | 2006-09-26 | 2006-09-26 | 175 | 465d |  | IEA: Business Architecture Team | N/A |  |  |  |  | Yes | Yes | Done |  |
| 177 | 1.4.2.15 | Updated BFA To-Be Services and Systems Diagram (if applicable) | milestone | 0d | 2006-09-26 | 2006-09-26 | 175 | 465d |  | None | N/A |  |  |  |  | Yes | Yes | Medium |  |
| 178 | 1.4.2.16 | Updated BFA Data Standards Document (if applicable) | milestone | 0d | 2006-09-26 | 2006-09-26 | 175 | 465d |  | IEA: Business Architecture Team | N/A | Yes |  |  |  | Yes |  |  |  |
| 179 | 1.4.2.17 | Recommendations and Findings Presentation | milestone | 0d | 2006-09-26 | 2006-09-26 | 175 | 465d |  | IEA: Business Architecture Team,IEA: Data Architecture Team | N/A | Yes |  |  |  |  |  | Medium |  |

Notes:
- 169: Concept for implementation in System Architect: / Same as above.
- 171: Concept for implementation in System Architect: / Same as above.
- 172: Concept for implementation in System Architect: / Will be BFA Centric System Interface diagram with use of Services. / ALBERT SPACESHIP
- 177: Concept for implementation in System Architect: / Will be BFA Centric System Interface diagram with use of Services. / ALBERT SPACESHIP

| ID | WBS | Task | Type | Duration | Start | Finish | Predecessors | Total slack | Free slack | Text13 | Text24 | Text30 | Text2 | Text4 | Text18 | Text1 | Text3 |
| --- | --- | --- | --- | --- | --- | --- | --- | --- | --- | --- | --- | --- | --- | --- | --- | --- | --- |
| 180 | 1.4.3 | **Step 9: Conduct data standardization** |  | 135d | 2006-09-27 | 2007-04-03 |  | 465d |  | IEA: Data Architecture Team | Craig | Jerad |  |  |  |  |  |
| 181 | 1.4.3.1 | Review Blueprint and BPR References |  | 5d | 2006-09-27 | 2006-10-03 | 162 | 465d | 0d | IEA: Data Architecture Team |  |  |  |  |  |  |  |
| 182 | 1.4.3.2 | Logical Data Model | milestone | 0d | 2006-10-03 | 2006-10-03 | 181 | 595d |  | IEA: Data Architecture Team |  |  | Yes | DONE |  |  |  |
| 183 | 1.4.3.3 | Identify Data Requirements and Develop Data Standards |  | 15d | 2006-10-04 | 2006-10-24 | 181 | 465d | 0d | IEA: Data Architecture Team |  |  |  |  |  |  |  |
| 184 | 1.4.3.4 | Data Proposal Package | milestone | 0d | 2006-10-24 | 2006-10-24 | 183 | 580d |  | IEA: Data Architecture Team |  |  | Yes | DONE | Yes |  |  |
| 185 | 1.4.3.5 | Review and Adopt Data Standards |  | 25d | 2006-10-25 | 2006-11-28 | 183 | 465d | 0d | IEA: Data Architecture Team |  |  |  |  |  |  |  |
| 186 | 1.4.3.6 | Adopted or Rejected DOI Data Standards | milestone | 0d | 2006-11-28 | 2006-11-28 | 185 | 555d |  | IEA: Data Architecture Team |  |  |  | N/A |  |  |  |
| 187 | 1.4.3.7 | Possible Changes to a Proposal Package for Resubmission | milestone | 0d | 2006-11-28 | 2006-11-28 | 185 | 555d |  | IEA: Data Architecture Team |  |  |  | N/A |  |  |  |
| 188 | 1.4.3.8 | Implement Data Standards |  | 90d | 2006-11-29 | 2007-04-03 | 185 | 465d | 0d | IEA: Data Architecture Team |  |  |  |  |  |  |  |
| 189 | 1.4.3.9 | Interior Data Reference Model | milestone | 0d | 2007-04-03 | 2007-04-03 | 188 | 465d |  | IEA: Data Architecture Team |  |  |  | N/A | Yes |  |  |
| 190 | 1.4.3.10 | XML Tags and Schemas | milestone | 0d | 2007-04-03 | 2007-04-03 | 188 | 465d |  | IEA: Data Architecture Team |  |  |  | N/A | Yes |  |  |
| 191 | 1.4.3.11 | Information Exchange Packages | milestone | 0d | 2007-04-03 | 2007-04-03 | 188 | 465d |  | IEA: Data Architecture Team |  |  |  | N/A | Yes |  |  |
| 192 | 1.4.3.12 | Physical Database Schemas | milestone | 0d | 2007-04-03 | 2007-04-03 | 188 | 465d |  | IEA: Data Architecture Team |  |  |  | N/A | Yes |  |  |
| 193 | 1.4.4 | **Step 10A: Execute O&M funding strategy for minor recommendations** |  | 120d | 2005-02-09 | 2005-07-26 |  | 905d |  |  | None | None |  |  |  |  |  |
| 194 | 1.4.4.1 | Execute O&M funding strategy for minor recommendations |  | 120d | 2005-02-09 | 2005-07-26 |  | 905d |  | None |  |  |  |  |  |  |  |
| 195 | 1.4.5 | **Step 10B: Incorporate major recommendations into investment request (as necessary)** |  | 60d | 2006-05-17 | 2006-08-08 |  | 635d |  |  | Albert | Jim |  |  |  |  |  |
| 196 | 1.4.5.1 | Formulate CPIC pre-select recommendations from Blueprint items funded outside of O&M |  | 20d | 2006-05-17 | 2006-06-13 | 143 | 635d | 0d | IEA: Business Architecture Team |  |  |  |  |  |  |  |
| 197 | 1.4.5.2 | CPIC Pre-Select Documents | milestone | 0d | 2006-06-13 | 2006-06-13 | 196 | 675d |  | IEA: Business Architecture Team |  |  |  | N/A | Yes | Yes |  |
| 198 | 1.4.5.3 | Present major recommendations as pre-select candidates to IRB |  | 5d | 2006-06-14 | 2006-06-20 | 196 | 635d | 0d | IEA: Business Architecture Team |  |  |  |  |  |  |  |
| 199 | 1.4.5.4 | CPIC Pre-Select Presentation to IRB | milestone | 0d | 2006-06-20 | 2006-06-20 | 198 | 670d |  | IEA: Business Architecture Team |  |  |  | N/A | Yes |  |  |
| 200 | 1.4.5.5 | Author the Exhibit 300 from the approved Blueprint |  | 20d | 2006-06-21 | 2006-07-18 | 198 | 635d | 0d | IEA: Business Architecture Team |  |  |  |  |  |  |  |
| 201 | 1.4.5.6 | Draft Exhibit 300 | milestone | 0d | 2006-07-18 | 2006-07-18 | 200 | 650d |  | IEA: Business Architecture Team |  |  |  | N/A |  | Yes | Yes |
| 202 | 1.4.5.7 | Brief CMIT on Exhibit 300 and obtain content approval |  | 5d | 2006-07-19 | 2006-07-25 | 200 | 635d | 0d | IEA: Business Architecture Team |  |  |  |  |  |  |  |
| 203 | 1.4.5.8 | Updated Draft Exhibit 300 | milestone | 0d | 2006-07-25 | 2006-07-25 | 202 | 645d |  | IEA: Business Architecture Team |  |  |  | N/A | Yes, external | Yes | Yes |
| 204 | 1.4.5.9 | Submit Exhibit 300 to CPIC |  | 5d | 2006-07-26 | 2006-08-01 | 202 | 635d | 0d | IEA: Business Architecture Team |  |  |  |  |  |  |  |
| 205 | 1.4.5.10 | Updated Draft Exhibit 300 | milestone | 0d | 2006-08-01 | 2006-08-01 | 204 | 640d |  | IEA: Business Architecture Team |  |  |  | N/A | Yes, external | Yes | Yes |
| 206 | 1.4.5.11 | Obtain approval of Exhibit 300 |  | 5d | 2006-08-02 | 2006-08-08 | 204 | 635d | 0d | IEA: Business Architecture Team |  |  |  |  |  |  |  |
| 207 | 1.4.5.12 | Approved Exhibit 300 | milestone | 0d | 2006-08-08 | 2006-08-08 | 206 | 635d |  | IEA: Business Architecture Team |  |  |  | N/A | Yes, external | Yes | Yes |

Notes:
- 197: SA implementation recomendation: / Attribute on Finding to flag when will go to the pre-select/select stage.

| ID | WBS | Task | Type | Duration | Start | Finish | Predecessors | Total slack | Free slack | Text24 | Text30 | Text13 | Text1 | Text4 | Text18 | Text23 | Text3 | Text14 | Text2 |
| --- | --- | --- | --- | --- | --- | --- | --- | --- | --- | --- | --- | --- | --- | --- | --- | --- | --- | --- | --- |
| 208 | 1.4.6 | **Step 11: Define detailed solution architecture** |  | 125d | 2006-05-17 | 2006-11-07 |  | 0d |  | Fred | Jerad |  |  |  |  |  |  |  |  |
| 209 | 1.4.6.1 | Form solution architecture team (IPT with contracts) |  | 15d | 2006-05-17 | 2006-06-06 | 143 | 0d |  |  |  | Solution Architecture Team |  |  |  |  |  |  |  |
| 210 | 1.4.6.2 | Solution Architecture Team Roster Document | milestone | 0d | 2006-06-06 | 2006-06-06 | 209 | 110d |  |  |  | Solution Architecture Team | Yes | N/A | Yes | Yes |  |  |  |
| 211 | 1.4.6.3 | Define detailed solution architecture |  | 60d | 2006-06-07 | 2006-08-29 | 209 | 0d |  |  |  | Solution Architecture Team |  |  |  |  |  |  |  |
| 212 | 1.4.6.4 | Interior Data Reference Model | milestone | 0d | 2006-08-29 | 2006-08-29 | 211 | 50d |  |  |  | IEA: Data Architecture Team |  | N/A |  |  | Yes | Medium |  |
| 213 | 1.4.6.5 | Detailed Solution Architecture | milestone | 0d | 2006-08-29 | 2006-08-29 | 211 | 50d |  |  |  | Solution Architecture Team | Yes | N/A | ?? | Yes | ?? |  | ?? |
| 214 | 1.4.6.6 | Validate solution architecture against enterprise architecture |  | 30d | 2006-08-30 | 2006-10-10 | 211 | 0d |  |  |  | Solution Architecture Team |  |  |  |  |  |  |  |
| 215 | 1.4.6.7 | Submit solution architecture for CMIT approval |  | 10d | 2006-10-11 | 2006-10-24 | 214 | 0d |  |  |  | Solution Architecture Team |  |  |  |  |  |  |  |
| 216 | 1.4.6.8 | Submit solution architecture for IBAT/CTOC review |  | 10d | 2006-10-25 | 2006-11-07 | 215 | 0d |  |  |  | Solution Architecture Team |  |  |  |  |  |  |  |
| 217 | 1.4.7 | **Step 12: Implement solution and conduct change management tasks** |  | 570d | 2006-11-08 | 2009-01-13 |  | 0d |  | Jerad | Jim |  |  |  |  |  |  |  |  |
| 218 | 1.4.7.1 | Solicit hardware/software/professional services as needed |  | 90d | 2006-11-08 | 2007-03-13 | 208 | 0d |  |  |  | Office of Acquisition and Property Management |  |  |  |  |  |  |  |
| 219 | 1.4.7.2 | Request for Proposal Document | milestone | 0d | 2007-03-13 | 2007-03-13 | 218 | 480d |  |  |  | IEA: Business Architecture Team | Yes | N/A |  |  |  |  |  |
| 220 | 1.4.7.3 | Proposal Evaluation Criteria Document | milestone | 0d | 2007-03-13 | 2007-03-13 | 218 | 480d |  |  |  | IEA: Business Architecture Team | Yes | N/A |  |  |  |  |  |
| 221 | 1.4.7.4 | Acquire hardware/software/professional services as needed |  | 90d | 2007-03-14 | 2007-07-17 | 218 | 0d |  |  |  | Office of Acquisition and Property Management |  |  |  |  |  |  |  |
| 222 | 1.4.7.5 | Evaluated Proposals | milestone | 0d | 2007-07-17 | 2007-07-17 | 221 | 390d |  |  |  | IEA: Business Architecture Team | Yes | N/A |  |  |  |  |  |
| 223 | 1.4.7.6 | Selected Proposal | milestone | 0d | 2007-07-17 | 2007-07-17 | 221 | 390d |  |  |  | IEA: Business Architecture Team | Yes | N/A |  |  |  |  |  |
| 224 | 1.4.7.7 | Implement solution and conduct outreach briefings to management / staff |  | 360d | 2007-07-18 | 2008-12-02 | 221 | 0d |  |  |  | None |  |  |  |  |  |  |  |
| 225 | 1.4.7.8 | Final Solution Requirements Document | milestone | 0d | 2008-12-02 | 2008-12-02 | 224 | 30d |  |  |  | IEA: Business Architecture Team | Yes | N/A |  |  |  |  |  |
| 226 | 1.4.7.9 | Implemented Solution | milestone | 0d | 2008-12-02 | 2008-12-02 | 224 | 30d |  |  |  | IEA: Business Architecture Team | Yes | N/A |  |  |  |  |  |
| 227 | 1.4.7.10 | Enterprise Level Solution Presentations | milestone | 0d | 2008-12-02 | 2008-12-02 | 224 | 30d |  |  |  | IEA: Business Architecture Team | Yes | N/A | Yes |  |  |  |  |
| 228 | 1.4.7.11 | Formulate and issue new policy resulting from solution implementation |  | 180d | 2007-03-14 | 2007-11-20 | 218 | 300d | 0d |  |  | IEA: Business Architecture Team |  |  |  | Yes |  |  |  |
| 229 | 1.4.7.12 | Policy Memo Document(s) | milestone | 0d | 2007-11-20 | 2007-11-20 | 228 | 300d |  |  |  | IEA: Business Architecture Team | Yes | N/A | Yes |  |  |  |  |
| 230 | 1.4.7.13 | Implement organizational change recommendations |  | 180d | 2007-03-14 | 2007-11-20 | 218 | 300d |  |  |  | IEA: Business Architecture Team |  |  |  | Yes |  |  |  |
| 231 | 1.4.7.14 | Construct and implement training strategy based on BPR and solution architecture |  | 90d | 2007-03-14 | 2007-07-17 | 218 | 390d | 0d |  |  | IEA: Business Architecture Team |  |  |  | Yes |  |  |  |
| 232 | 1.4.7.15 | Training Strategy/Curriculum Document | milestone | 0d | 2007-07-17 | 2007-07-17 | 231 | 390d |  |  |  | IEA: Business Architecture Team |  | N/A | Yes |  |  |  |  |
| 233 | 1.4.7.16 | Evaluate solution against its intended purpose |  | 30d | 2008-12-03 | 2009-01-13 | 224 | 0d |  |  |  |  |  |  |  |  |  |  |  |

| ID | WBS | Task | Type | Duration | Start | Finish | Predecessors | Total slack | Free slack | Text24 | Text30 | Text13 | Text4 | Text18 |
| --- | --- | --- | --- | --- | --- | --- | --- | --- | --- | --- | --- | --- | --- | --- |
| 234 | 1.5 | **Phase 5: Maintain the Blueprint** |  | 55d | 2005-02-09 | 2005-04-26 |  | 970d |  |  |  |  |  |  |
| 235 | 1.5.1 | **Step 13: Maintain the Blueprint and the architecture** |  | 55d | 2005-02-09 | 2005-04-26 |  | 970d |  | Jerad | Jim |  |  |  |
| 236 | 1.5.1.1 | Author Blueprint Appendix (architecture modification) and submit for CMBT review |  | 30d | 2005-02-09 | 2005-03-22 |  | 970d | 0d |  |  | IEA: Business Architecture Team,IEA: Data Architecture Team |  |  |
| 237 | 1.5.1.2 | Blueprint Appendix (architecture modification) | milestone | 0d | 2005-03-22 | 2005-03-22 | 236 | 995d |  |  |  | IEA: Business Architecture Team,IEA: Data Architecture Team | N/A | Yes |
| 238 | 1.5.1.3 | Submit Blueprint Appendix (architecture modification) to IBAT/CTOC for review |  | 15d | 2005-03-23 | 2005-04-12 | 236 | 970d | 0d |  |  | IEA: Business Architecture Team,IEA: Data Architecture Team |  |  |
| 239 | 1.5.1.4 | Architecture Modification Presentation | milestone | 0d | 2005-04-12 | 2005-04-12 | 238 | 980d |  |  |  | IEA: Business Architecture Team,IEA: Data Architecture Team | N/A | Yes |
| 240 | 1.5.1.5 | Brief the Architecture modifications to IRB and receive approval (if necessary) |  | 5d | 2005-04-13 | 2005-04-19 | 238 | 970d | 0d |  |  | IEA: Business Architecture Team,IEA: Data Architecture Team |  |  |
| 241 | 1.5.1.6 | Architecture Modification Presentation for IRB | milestone | 0d | 2005-04-19 | 2005-04-19 | 240 | 975d |  |  |  | IEA: Business Architecture Team,IEA: Data Architecture Team | N/A | Yes |
| 242 | 1.5.1.7 | Publish updated Blueprint and architecture artifacts |  | 5d | 2005-04-20 | 2005-04-26 | 240 | 970d | 0d |  |  | IEA: Business Architecture Team,IEA: Data Architecture Team |  |  |
| 243 | 1.5.1.8 | Updated Architecture Artifacts | milestone | 0d | 2005-04-26 | 2005-04-26 | 242 | 970d |  |  |  | IEA: Business Architecture Team,IEA: Data Architecture Team | N/A |  |
| 244 | 1.5.1.9 | Re-published Blueprint | milestone | 0d | 2005-04-26 | 2005-04-26 | 242 | 970d |  |  |  | IEA: Business Architecture Team,IEA: Data Architecture Team | N/A |  |
| 245 | 1.5.1.10 | Updated DOI Enterprise Artifacts | milestone | 0d | 2005-04-26 | 2005-04-26 | 242 | 970d |  |  |  | IEA: Business Architecture Team,IEA: Data Architecture Team | N/A |  |
